# MIT HANA Migration Schedule 20150715 V005

Schedule from MS Project, 2015-07-06 to 2015-09-11.

## Calendars

- Standard: Mon-Fri 08:00-12:00, 13:00-17:00; Sat-Sun off.

## Resources

| Resource |
| --- |
| 24 Hr Execution |
| Generic Resource |

## Schedule

| ID | WBS | Task | Type | Duration | Start | Finish | Predecessors | Total slack | Free slack | Constraint | Work |
| --- | --- | --- | --- | --- | --- | --- | --- | --- | --- | --- | --- |
| 1 | 1 | **Cycle 1 - Copy PS1 to SF3, Migrate to SF3-H** |  | 1.75mo | 2015-07-06 08:00 | 2015-08-21 17:00 |  | 15d |  |  | 973.5h |
| 2 | 1.1 | MIT System Copy PS1 - SF3 |  | 5d | 2015-07-06 08:00 | 2015-07-10 17:00 |  | 15.44d | 0d |  | 40h |
| 3 | 1.2 | XML Extract |  | 3h | 2015-07-13 08:00 | 2015-07-13 11:00 | 2 | 15.44d | 0d |  | 3h |
| 4 | 1.3 | Provision SF3 in HEC |  | 5d | 2015-07-06 08:00 | 2015-07-10 17:00 |  | 15.81d | 0d |  | 40h |
| 5 | 1.4 | **ECC (SF3)** |  | 1.65mo | 2015-07-08 08:00 | 2015-08-21 17:00 |  | 15d |  |  | 323.5h |
| 6 | 1.4.1 | **ECC Migration** |  | 3.6w | 2015-07-08 08:00 | 2015-07-31 17:00 |  | 15.06d |  |  | 203.5h |
| 7 | 1.4.1.1 | **General Preparation** |  | 4d | 2015-07-08 08:00 | 2015-07-13 17:00 |  | 15.06d |  |  | 60h |
| 8 | 1.4.1.1.1 | **MIT** |  | 2h | 2015-07-13 11:00 | 2015-07-13 14:00 |  | 15.44d | 0.38d |  | 24h |
| 9 | 1.4.1.1.1.1 | Pre-Migration Functional Snapshot |  | 2h | 2015-07-13 11:00 | 2015-07-13 14:00 | 3 | 15.44d |  |  | 2h |
| 10 | 1.4.1.1.1.2 | Update Oracle stats |  | 2h | 2015-07-13 11:00 | 2015-07-13 14:00 | 3 | 15.44d |  |  | 2h |
| 11 | 1.4.1.1.1.3 | Update Oracle dict stats |  | 2h | 2015-07-13 11:00 | 2015-07-13 14:00 | 3 | 15.44d |  |  | 2h |
| 12 | 1.4.1.1.1.4 | Update Oracle system stats |  | 2h | 2015-07-13 11:00 | 2015-07-13 14:00 | 3 | 15.44d |  |  | 2h |
| 13 | 1.4.1.1.1.5 | Check SPDD / SPAU |  | 2h | 2015-07-13 11:00 | 2015-07-13 14:00 | 3 | 15.44d |  |  | 2h |
| 14 | 1.4.1.1.1.6 | Generate a Migration Key |  | 2h | 2015-07-13 11:00 | 2015-07-13 14:00 | 3 | 15.44d |  |  | 2h |
| 15 | 1.4.1.1.1.7 | Disk Space SUM directry up to 20% of the database size |  | 2h | 2015-07-13 11:00 | 2015-07-13 14:00 | 3 | 15.44d |  |  | 2h |
| 16 | 1.4.1.1.1.8 | Check Consistency of Cluster Tables |  | 2h | 2015-07-13 11:00 | 2015-07-13 14:00 | 3 | 15.44d |  |  | 2h |
| 17 | 1.4.1.1.1.9 | Check Consistency of Pool Tables |  | 2h | 2015-07-13 11:00 | 2015-07-13 14:00 | 3 | 15.44d |  |  | 2h |
| 18 | 1.4.1.1.1.10 | Update the SAP Host Agent |  | 2h | 2015-07-13 11:00 | 2015-07-13 14:00 | 3 | 15.44d |  |  | 2h |
| 19 | 1.4.1.1.1.11 | Update R3* Tools |  | 2h | 2015-07-13 11:00 | 2015-07-13 14:00 | 3 | 15.44d |  |  | 2h |
| 20 | 1.4.1.1.1.12 | Generate MOPZ Stack Files |  | 2h | 2015-07-13 11:00 | 2015-07-13 14:00 | 3 | 15.44d |  |  | 2h |
| 21 | 1.4.1.1.2 | **HEC** |  | 4d | 2015-07-08 08:00 | 2015-07-13 17:00 |  | 15.06d | 0d |  | 36h |
| 22 | 1.4.1.1.2.1 | Validate SF3 System |  | 2h | 2015-07-13 08:00 | 2015-07-13 10:00 | 4 | 15.81d |  |  | 2h |
| 23 | 1.4.1.1.2.2 | Resize File Space for SF3? |  | 2h | 2015-07-13 08:00 | 2015-07-13 10:00 | 4 | 15.81d |  |  | 2h |
| 24 | 1.4.1.1.2.3 | Ship Disks from SAP to MIT |  | 4d | 2015-07-08 08:00 | 2015-07-13 17:00 |  | 15.06d | 0d | start no earlier than 2015-07-08 00:00 | 32h |
| 25 | 1.4.1.1.3 | Preparation Completed | milestone | 0d | 2015-07-13 17:00 | 2015-07-13 17:00 | 8, 21 | 15.06d | 0d |  |  |

| ID | WBS | Task | Type | Duration | Start | Finish | Predecessors | Total slack | Free slack | Resources | Work |
| --- | --- | --- | --- | --- | --- | --- | --- | --- | --- | --- | --- |
| 26 | 1.4.1.2 | **DMO Uptime Phase** |  | 1d | 2015-07-14 08:00 | 2015-07-15 00:30 |  | 15.06d | 0d |  | 15.5h |
| 27 | 1.4.1.2.1 | Configure Host Agent for DMO |  | 0.5h | 2015-07-14 08:00 | 2015-07-14 08:30 | 25 | 15.06d | 0d |  | 0.5h |
| 28 | 1.4.1.2.2 | Extraction |  | 1h | 2015-07-14 08:30 | 2015-07-14 09:30 | 27 | 15.06d | 0d |  | 1h |
| 29 | 1.4.1.2.3 | Configuration |  | 2h | 2015-07-14 09:30 | 2015-07-14 11:30 | 28 | 15.06d | 0d |  | 2h |
| 30 | 1.4.1.2.4 | Checks |  | 4h | 2015-07-14 11:30 | 2015-07-14 16:30 | 29 | 15.06d | 0d |  | 4h |
| 31 | 1.4.1.2.5 | Pre-Processing |  | 8h | 2015-07-14 16:30 | 2015-07-15 00:30 | 30 | 15.06d |  | 24 Hr Execution | 8h |
| 32 | 1.4.1.3 | **Source System Rampdown** |  | 4.5h | 2015-07-15 08:00 | 2015-07-15 13:30 |  | 15.31d | 0d |  | 6.5h |
| 33 | 1.4.1.3.1 | Lock Users |  | 0.5h | 2015-07-15 08:00 | 2015-07-15 08:30 | 26 | 15.31d | 0d |  | 0.5h |
| 34 | 1.4.1.3.2 | Validate all Jobs are Completed |  | 2h | 2015-07-15 08:30 | 2015-07-15 10:30 | 33 | 15.31d | 0d |  | 2h |
| 35 | 1.4.1.3.3 | MIT Shutdown Activities go Here |  | 2h | 2015-07-15 10:30 | 2015-07-15 13:30 | 34 | 15.31d |  |  | 2h |
| 36 | 1.4.1.3.4 | Checks for Open Updates, Failed Updates, etc. |  | 2h | 2015-07-15 10:30 | 2015-07-15 13:30 | 34 | 15.31d |  |  | 2h |
| 37 | 1.4.1.4 | **DMO Downtime Phase** |  | 3.5h | 2015-07-15 13:30 | 2015-07-15 22:30 |  | 15d |  |  | 9h |
| 38 | 1.4.1.4.1 | Pre-Procesing Continued |  | 1h | 2015-07-15 13:30 | 2015-07-15 14:30 | 32 | 15.31d | 0d |  | 1h |
| 39 | 1.4.1.4.2 | Execution - Export |  | 8h | 2015-07-15 14:30 | 2015-07-15 22:30 | 38 | 15d | 0d | 24 Hr Execution | 8h |
| 40 | 1.4.1.5 | **Copy to Disk** |  | 2d | 2015-07-14 08:00 | 2015-07-16 04:30 |  | 15.56d |  |  | 7h |
| 41 | 1.4.1.5.1 | Mount Disk 1 |  | 1h | 2015-07-14 08:00 | 2015-07-14 09:00 | 24 | 16.88d | 1.88d |  | 1h |
| 42 | 1.4.1.5.2 | Copy SUM Directory to Disk |  | 6h | 2015-07-15 22:30 | 2015-07-16 04:30 | 39, 41 | 15d | 0d | 24 Hr Execution | 6h |
| 43 | 1.4.1.6 | **rsync Test** |  | 0d | 2015-07-15 22:30 | 2015-07-15 22:30 |  | 42d |  |  |  |
| 44 | 1.4.1.6.1 | Commence rsync Copy Over VPN as Backup & Test | milestone | 0d | 2015-07-15 22:30 | 2015-07-15 22:30 | 39 | 42d |  |  |  |
| 45 | 1.4.1.7 | **Ship Disk from MIT to SAP** |  | 2d | 2015-07-16 08:00 | 2015-07-17 17:30 |  | 15d |  |  | 17.5h |
| 46 | 1.4.1.7.1 | Prep Disk for Shipping |  | 0.5h | 2015-07-16 08:00 | 2015-07-16 08:30 | 42 | 15.56d | 0d |  | 0.5h |
| 47 | 1.4.1.7.2 | Overnight FedEx |  | 1d | 2015-07-16 08:30 | 2015-07-17 08:30 | 46 | 15.56d | 0d |  | 8h |
| 48 | 1.4.1.7.3 | Receive Disk at HEC & Mount to Server |  | 3h | 2015-07-17 08:30 | 2015-07-17 11:30 | 47 | 15.56d | 0d |  | 3h |
| 49 | 1.4.1.7.4 | Copy and Stage Contents of Disk |  | 6h | 2015-07-17 11:30 | 2015-07-17 17:30 | 48 | 15d | 0d | 24 Hr Execution | 6h |

| ID | WBS | Task | Duration | Start | Finish | Predecessors | Total slack | Free slack | Constraint | Resources | Work |
| --- | --- | --- | --- | --- | --- | --- | --- | --- | --- | --- | --- |
| 50 | 1.4.1.8 | **Resume DMO at HEC** | 0d | 2015-07-17 17:30 | 2015-07-18 01:30 |  | 15d |  |  |  | 8h |
| 51 | 1.4.1.8.1 | Continue Execution Phase (Import to HANA DB) | 8h | 2015-07-17 17:30 | 2015-07-18 01:30 | 25, 49 | 15d | 0d |  | 24 Hr Execution | 8h |
| 52 | 1.4.1.9 | **DMO Post Processing Phase** | 3h | 2015-07-20 08:00 | 2015-07-20 11:00 | 25, 49 | 15d |  |  |  | 3h |
| 53 | 1.4.1.9.1 | DMO Post Processing | 3h | 2015-07-20 08:00 | 2015-07-20 11:00 | 51 | 15d | 0d |  |  | 3h |
| 54 | 1.4.1.10 | Request Complete Backup of HANA DB | 4h | 2015-07-20 11:00 | 2015-07-20 16:00 | 53 | 15d | 0d |  |  | 4h |
| 55 | 1.4.1.11 | **Technical Post Processing** | 1.12d | 2015-07-20 16:00 | 2015-07-21 17:00 |  | 15d | 0d |  |  | 9h |
| 56 | 1.4.1.11.1 | Perform Post Processing per Checklist | 4h | 2015-07-20 16:00 | 2015-07-21 11:00 | 54 | 15d | 0d |  |  | 4h |
| 57 | 1.4.1.11.2 | RUN SGEN | 3h | 2015-07-21 11:00 | 2015-07-21 15:00 | 56 | 15d | 0d |  |  | 3h |
| 58 | 1.4.1.11.3 | **Placeholder for MIT Migration Post Processing** | 2h | 2015-07-21 15:00 | 2015-07-21 17:00 |  | 15d |  |  |  | 2h |
| 59 | 1.4.1.11.3.1 | Placeholder | 2h | 2015-07-21 15:00 | 2015-07-21 17:00 | 57 | 15d |  |  |  | 2h |
| 60 | 1.4.1.12 | HEC Post Migration Tasks | 4d | 2015-07-22 08:00 | 2015-07-27 17:00 | 55 | 15d | 0d |  |  | 32h |
| 61 | 1.4.1.13 | **ECC Prep for Testing** | 4d | 2015-07-28 08:00 | 2015-07-31 17:00 |  | 15d |  |  |  | 32h |
| 62 | 1.4.1.13.1 | Placeholder for Prep Tasks | 4d | 2015-07-28 08:00 | 2015-07-31 17:00 | 60 | 15d | 0d |  |  | 32h |
| 63 | 1.4.2 | **ECC Testing** | 3w | 2015-08-03 08:00 | 2015-08-21 17:00 |  | 15d |  |  |  | 120h |
| 64 | 1.4.2.1 | Integrated Testing | 3w | 2015-08-03 08:00 | 2015-08-21 17:00 | 62, 65, 70 | 15d |  |  |  | 120h |
| 65 | 1.5 | **BSI (BSD)** | 2w | 2015-07-13 08:00 | 2015-07-24 17:00 |  | 20d | 5d |  |  | 120h |
| 66 | 1.5.1 | Provision BSI (BSD) Server in HEC | 5d | 2015-07-13 08:00 | 2015-07-17 17:00 |  | 20d | 0d | start no earlier than 2015-07-13 08:00 |  | 40h |
| 67 | 1.5.2 | Install & Configure BSI in HEC | 5d | 2015-07-20 08:00 | 2015-07-24 17:00 | 66 | 20d |  |  |  | 40h |
| 68 | 1.5.3 | **Backup Plan to Use BSI on Prem at MIT** | 1w | 2015-07-16 08:00 | 2015-07-22 17:00 |  | 22d |  |  |  | 40h |
| 69 | 1.5.3.1 | Test Connectivity from BSI to MIT | 5d | 2015-07-16 08:00 | 2015-07-22 17:00 |  | 22d |  | start no earlier than 2015-07-16 00:00 |  | 40h |
| 70 | 1.6 | **SSO Kerberos** | 1w | 2015-07-09 08:00 | 2015-07-15 17:00 |  | 27d | 12d |  |  | 40h |
| 71 | 1.6.1 | Set up ECC on HEC for Test | 3d | 2015-07-09 08:00 | 2015-07-13 17:00 |  | 27d | 0d | start no earlier than 2015-07-09 08:00 |  | 24h |
| 72 | 1.6.2 | Test and Debug | 2d | 2015-07-14 08:00 | 2015-07-15 17:00 | 71 | 27d |  |  |  | 16h |
| 73 | 1.7 | **ADS (DSD)** | 2w | 2015-07-20 08:00 | 2015-07-31 17:00 |  | 30d |  |  |  | 80h |
| 74 | 1.7.1 | Provision ADS (DSD) in HEC | 5d | 2015-07-20 08:00 | 2015-07-24 17:00 |  | 30d | 0d | start no earlier than 2015-07-20 00:00 |  | 40h |
| 75 | 1.7.2 | Configure ADS (DSD) | 5d | 2015-07-27 08:00 | 2015-07-31 17:00 | 74 | 30d |  |  |  | 40h |

| ID | WBS | Task | Duration | Start | Finish | Predecessors | Total slack | Free slack | Constraint | Resources | Work |
| --- | --- | --- | --- | --- | --- | --- | --- | --- | --- | --- | --- |
| 76 | 1.8 | **OpenText (NonPRD)** | 2w | 2015-07-13 08:00 | 2015-07-24 17:00 |  | 35d |  |  |  | 80h |
| 77 | 1.8.1 | Provision OpenText in HEC (NonPRD) | 5d | 2015-07-13 08:00 | 2015-07-17 17:00 |  | 35d | 0d | start no earlier than 2015-07-13 08:00 |  | 40h |
| 78 | 1.8.2 | Configure OpenText (NonPRD) | 5d | 2015-07-20 08:00 | 2015-07-24 17:00 | 77 | 35d |  |  |  | 40h |
| 79 | 1.9 | **SFTP Server (Prod)** | 2w | 2015-07-06 08:00 | 2015-07-17 17:00 |  | 40d |  |  |  | 80h |
| 80 | 1.9.1 | Provision SFTP Server (Prod) | 5d | 2015-07-13 08:00 | 2015-07-17 17:00 |  | 40d |  | start no earlier than 2015-07-13 00:00 |  | 40h |
| 81 | 1.9.2 | Configure SFTP Server (Prod) | 5d | 2015-07-06 08:00 | 2015-07-10 17:00 |  | 45d |  |  |  | 40h |
| 82 | 1.10 | **GRC (ACD)** | 3w | 2015-07-06 08:00 | 2015-07-24 17:00 |  | 35d |  |  |  | 87h |
| 83 | 1.10.1 | Provision GRC in HEC | 5d | 2015-07-20 08:00 | 2015-07-24 17:00 |  | 35d |  | start no earlier than 2015-07-20 00:00 |  | 40h |
| 84 | 1.10.2 | Ship Disks to MIT for GRC | 2d | 2015-07-16 08:00 | 2015-07-17 17:00 |  | 40d |  | start no earlier than 2015-07-16 00:00 |  | 16h |
| 85 | 1.10.3 | **Export GRC from MIT** | 2.6w | 2015-07-06 08:00 | 2015-07-23 01:00 |  | 37d |  |  |  | 31h |
| 86 | 1.10.3.1 | SWPM Export of GRC | 2d | 2015-07-21 08:00 | 2015-07-22 17:00 |  | 36.12d | 0d | start no earlier than 2015-07-21 08:00 |  | 16h |
| 87 | 1.10.3.2 | **Copy to Disk** | 6h | 2015-07-06 08:00 | 2015-07-06 15:00 |  | 49.25d |  |  |  | 7h |
| 88 | 1.10.3.2.1 | Mount Disk 1 | 1h | 2015-07-06 08:00 | 2015-07-06 09:00 |  | 49.25d | 0d |  |  | 1h |
| 89 | 1.10.3.2.2 | Copy SUM Directory to Disk | 6h | 2015-07-06 09:00 | 2015-07-06 15:00 | 88 | 49.25d |  |  | 24 Hr Execution | 6h |
| 90 | 1.10.3.3 | SFTP Transfer of GRC Production to SFTP Server | 8h | 2015-07-22 17:00 | 2015-07-23 01:00 | 86 | 36.12d |  |  | 24 Hr Execution | 8h |
| 91 | 1.11 | **SolMan (MST)** | 2w | 2015-07-13 08:00 | 2015-07-24 17:00 |  | 35d |  |  |  | 80h |
| 92 | 1.11.1 | Provision SolMan (MST) | 5d | 2015-07-13 08:00 | 2015-07-17 17:00 |  | 35d | 0d | start no earlier than 2015-07-13 00:00 |  | 40h |
| 93 | 1.11.2 | Configure SolMan (MST) | 5d | 2015-07-20 08:00 | 2015-07-24 17:00 | 92 | 35d |  |  |  | 40h |
| 94 | 2 | **Cycle 2 (DEV 1)** | 1.75mo | 2015-07-27 08:00 | 2015-09-11 17:00 |  | 0d |  |  |  | 355.5h |
| 95 | 2.1 | **ECC (SF2)** | 1.75mo | 2015-07-27 08:00 | 2015-09-11 17:00 |  | 0d |  |  |  | 355.5h |
| 96 | 2.1.1 | Provistion ECC (SF2) in HEC | 4d | 2015-08-03 08:00 | 2015-08-06 17:00 |  | 26d |  | start no earlier than 2015-08-03 00:00 |  | 32h |
| 97 | 2.1.2 | **ECC Migration** | 1mo | 2015-07-27 08:00 | 2015-08-21 17:00 |  | 2.06d |  |  |  | 203.5h |
| 98 | 2.1.2.1 | **General Preparation** | 1.05w | 2015-07-27 08:00 | 2015-08-03 10:00 |  | 0.81d |  |  |  | 60h |
| 99 | 2.1.2.1.1 | **MIT** | 2h | 2015-08-03 08:00 | 2015-08-03 10:00 |  | 0.81d | 0d |  |  | 24h |
| 100 | 2.1.2.1.1.1 | Pre-Migration Functional Snapshot | 2h | 2015-08-03 08:00 | 2015-08-03 10:00 |  | 0.81d |  | start no earlier than 2015-08-03 00:00 |  | 2h |
| 101 | 2.1.2.1.1.2 | Update Oracle stats | 2h | 2015-08-03 08:00 | 2015-08-03 10:00 |  | 0.81d |  | start no earlier than 2015-08-03 00:00 |  | 2h |
| 102 | 2.1.2.1.1.3 | Update Oracle dict stats | 2h | 2015-08-03 08:00 | 2015-08-03 10:00 |  | 0.81d |  | start no earlier than 2015-08-03 00:00 |  | 2h |
| 103 | 2.1.2.1.1.4 | Update Oracle system stats | 2h | 2015-08-03 08:00 | 2015-08-03 10:00 |  | 0.81d |  | start no earlier than 2015-08-03 00:00 |  | 2h |
| 104 | 2.1.2.1.1.5 | Check SPDD / SPAU | 2h | 2015-08-03 08:00 | 2015-08-03 10:00 |  | 0.81d |  | start no earlier than 2015-08-03 00:00 |  | 2h |
| 105 | 2.1.2.1.1.6 | Generate a Migration Key | 2h | 2015-08-03 08:00 | 2015-08-03 10:00 |  | 0.81d |  | start no earlier than 2015-08-03 00:00 |  | 2h |
| 106 | 2.1.2.1.1.7 | Disk Space SUM directry up to 20% of the database size | 2h | 2015-08-03 08:00 | 2015-08-03 10:00 |  | 0.81d |  | start no earlier than 2015-08-03 00:00 |  | 2h |
| 107 | 2.1.2.1.1.8 | Check Consistency of Cluster Tables | 2h | 2015-08-03 08:00 | 2015-08-03 10:00 |  | 0.81d |  | start no earlier than 2015-08-03 00:00 |  | 2h |
| 108 | 2.1.2.1.1.9 | Check Consistency of Pool Tables | 2h | 2015-08-03 08:00 | 2015-08-03 10:00 |  | 0.81d |  | start no earlier than 2015-08-03 00:00 |  | 2h |
| 109 | 2.1.2.1.1.10 | Update the SAP Host Agent | 2h | 2015-08-03 08:00 | 2015-08-03 10:00 |  | 0.81d |  | start no earlier than 2015-08-03 00:00 |  | 2h |
| 110 | 2.1.2.1.1.11 | Update R3* Tools | 2h | 2015-08-03 08:00 | 2015-08-03 10:00 |  | 0.81d |  | start no earlier than 2015-08-03 00:00 |  | 2h |
| 111 | 2.1.2.1.1.12 | Generate MOPZ Stack Files | 2h | 2015-08-03 08:00 | 2015-08-03 10:00 |  | 0.81d |  | start no earlier than 2015-08-03 00:00 |  | 2h |

| ID | WBS | Task | Type | Duration | Start | Finish | Predecessors | Total slack | Free slack | Constraint | Resources | Work |
| --- | --- | --- | --- | --- | --- | --- | --- | --- | --- | --- | --- | --- |
| 112 | 2.1.2.1.2 | **HEC** |  | 1.05w | 2015-07-27 08:00 | 2015-08-03 10:00 |  | 0.81d | 0d |  |  | 36h |
| 113 | 2.1.2.1.2.1 | Validate SF3 System |  | 2h | 2015-08-03 08:00 | 2015-08-03 10:00 |  | 0.81d |  | start no earlier than 2015-08-03 08:00 |  | 2h |
| 114 | 2.1.2.1.2.2 | Resize File Space for SF3? |  | 2h | 2015-08-03 08:00 | 2015-08-03 10:00 |  | 0.81d |  | start no earlier than 2015-08-03 08:00 |  | 2h |
| 115 | 2.1.2.1.2.3 | Ship Disks from SAP to MIT |  | 4d | 2015-07-27 08:00 | 2015-07-30 17:00 |  | 2.06d | 0d | start no earlier than 2015-07-27 08:00 |  | 32h |
| 116 | 2.1.2.1.3 | Preparation Completed | milestone | 0d | 2015-08-03 10:00 | 2015-08-03 10:00 | 99, 112 | 0.81d | 0d |  |  |  |
| 117 | 2.1.2.2 | **DMO Uptime Phase** |  | 1.75d | 2015-08-03 10:00 | 2015-08-04 17:30 |  | 0.31d | 0d |  |  | 15.5h |
| 118 | 2.1.2.2.1 | Configure Host Agent for DMO |  | 0.5h | 2015-08-03 10:00 | 2015-08-03 10:30 | 116 | 0.81d | 0d |  |  | 0.5h |
| 119 | 2.1.2.2.2 | Extraction |  | 1h | 2015-08-03 10:30 | 2015-08-03 11:30 | 118 | 0.81d | 0d |  |  | 1h |
| 120 | 2.1.2.2.3 | Configuration |  | 2h | 2015-08-03 11:30 | 2015-08-03 14:30 | 119 | 0.81d | 0d |  |  | 2h |
| 121 | 2.1.2.2.4 | Checks |  | 4h | 2015-08-03 14:30 | 2015-08-04 09:30 | 120 | 0.81d | 0d |  |  | 4h |
| 122 | 2.1.2.2.5 | Pre-Processing |  | 8h | 2015-08-04 09:30 | 2015-08-04 17:30 | 121 | 0.31d |  |  | 24 Hr Execution | 8h |
| 123 | 2.1.2.3 | **Source System Rampdown** |  | 4.5h | 2015-08-05 08:00 | 2015-08-05 13:30 |  | 0.31d | 0d |  |  | 6.5h |
| 124 | 2.1.2.3.1 | Lock Users |  | 0.5h | 2015-08-05 08:00 | 2015-08-05 08:30 | 117 | 0.31d | 0d |  |  | 0.5h |
| 125 | 2.1.2.3.2 | Validate all Jobs are Completed |  | 2h | 2015-08-05 08:30 | 2015-08-05 10:30 | 124 | 0.31d | 0d |  |  | 2h |
| 126 | 2.1.2.3.3 | MIT Shutdown Activities go Here |  | 2h | 2015-08-05 10:30 | 2015-08-05 13:30 | 125 | 0.31d |  |  |  | 2h |
| 127 | 2.1.2.3.4 | Checks for Open Updates, Failed Updates, etc. |  | 2h | 2015-08-05 10:30 | 2015-08-05 13:30 | 125 | 0.31d |  |  |  | 2h |
| 128 | 2.1.2.4 | **DMO Downtime Phase** |  | 3.5h | 2015-08-05 13:30 | 2015-08-05 22:30 |  | 0d |  |  |  | 9h |
| 129 | 2.1.2.4.1 | Pre-Procesing Continued |  | 1h | 2015-08-05 13:30 | 2015-08-05 14:30 | 123 | 0.31d | 0d |  |  | 1h |
| 130 | 2.1.2.4.2 | Execution - Export |  | 8h | 2015-08-05 14:30 | 2015-08-05 22:30 | 129 | 0d |  |  | 24 Hr Execution | 8h |
| 131 | 2.1.2.5 | **Copy to Disk** |  | 4d | 2015-07-31 08:00 | 2015-08-06 04:30 |  | 0.56d |  |  |  | 7h |
| 132 | 2.1.2.5.1 | Mount Disk 1 |  | 1h | 2015-07-31 08:00 | 2015-07-31 09:00 | 115 | 3.88d |  |  |  | 1h |
| 133 | 2.1.2.5.2 | Copy SUM Directory to Disk |  | 6h | 2015-08-05 22:30 | 2015-08-06 04:30 | 130, 132 | 0d |  |  | 24 Hr Execution | 6h |
| 134 | 2.1.2.6 | **rsync Test** |  | 0d | 2015-08-07 22:30 | 2015-08-07 22:30 |  | 25d |  |  |  |  |
| 135 | 2.1.2.6.1 | Commence rsync Copy Over VPN as Backup & Test | milestone | 0d | 2015-08-07 22:30 | 2015-08-07 22:30 | 130 | 25d |  | start no earlier than 2015-08-07 22:30 |  |  |

| ID | WBS | Task | Duration | Start | Finish | Predecessors | Total slack | Free slack | Constraint | Resources | Work |
| --- | --- | --- | --- | --- | --- | --- | --- | --- | --- | --- | --- |
| 136 | 2.1.2.7 | **Ship Disk from MIT to SAP** | 2d | 2015-08-06 08:00 | 2015-08-07 17:30 |  | 0d |  |  |  | 17.5h |
| 137 | 2.1.2.7.1 | Prep Disk for Shipping | 0.5h | 2015-08-06 08:00 | 2015-08-06 08:30 | 133 | 0.56d | 0d |  |  | 0.5h |
| 138 | 2.1.2.7.2 | Overnight FedEx | 1d | 2015-08-06 08:30 | 2015-08-07 08:30 | 137 | 0.56d | 0d |  |  | 8h |
| 139 | 2.1.2.7.3 | Receive Disk at HEC & Mount to Server | 3h | 2015-08-07 08:30 | 2015-08-07 11:30 | 138 | 0.56d | 0d |  |  | 3h |
| 140 | 2.1.2.7.4 | Copy and Stage Contents of Disk | 6h | 2015-08-07 11:30 | 2015-08-07 17:30 | 139 | 0d |  |  | 24 Hr Execution | 6h |
| 141 | 2.1.2.8 | **Resume DMO at HEC** | 0d | 2015-08-07 17:30 | 2015-08-08 01:30 |  | 0d |  |  |  | 8h |
| 142 | 2.1.2.8.1 | Continue Execution Phase (Import to HANA DB) | 8h | 2015-08-07 17:30 | 2015-08-08 01:30 | 116, 140 | 0d |  |  | 24 Hr Execution | 8h |
| 143 | 2.1.2.9 | **DMO Post Processing Phase** | 3h | 2015-08-10 08:00 | 2015-08-10 11:00 | 116, 140 | 0d |  |  |  | 3h |
| 144 | 2.1.2.9.1 | DMO Post Processing | 3h | 2015-08-10 08:00 | 2015-08-10 11:00 | 142 | 0d |  |  |  | 3h |
| 145 | 2.1.2.10 | Request Complete Backup of HANA DB | 4h | 2015-08-10 11:00 | 2015-08-10 16:00 | 144 | 0d |  |  |  | 4h |
| 146 | 2.1.2.11 | **Technical Post Processing** | 1.12d | 2015-08-10 16:00 | 2015-08-11 17:00 |  | 0d |  |  |  | 9h |
| 147 | 2.1.2.11.1 | Perform Post Processing per Checklist | 4h | 2015-08-10 16:00 | 2015-08-11 11:00 | 145 | 0d |  |  |  | 4h |
| 148 | 2.1.2.11.2 | RUN SGEN | 3h | 2015-08-11 11:00 | 2015-08-11 15:00 | 147 | 0d |  |  |  | 3h |
| 149 | 2.1.2.11.3 | **Placeholder for MIT Migration Post Processing** | 2h | 2015-08-11 15:00 | 2015-08-11 17:00 |  | 0d |  |  |  | 2h |
| 150 | 2.1.2.11.3.1 | Placeholder | 2h | 2015-08-11 15:00 | 2015-08-11 17:00 | 148 | 0d |  |  |  | 2h |
| 151 | 2.1.2.12 | HEC Post Migration Tasks | 4d | 2015-08-12 08:00 | 2015-08-17 17:00 | 146 | 0d |  |  |  | 32h |
| 152 | 2.1.2.13 | **ECC Prep for Testing** | 4d | 2015-08-18 08:00 | 2015-08-21 17:00 |  | 0d |  |  |  | 32h |
| 153 | 2.1.2.13.1 | Placeholder for Prep Tasks | 4d | 2015-08-18 08:00 | 2015-08-21 17:00 | 151 | 0d |  |  |  | 32h |
| 154 | 2.1.3 | **ECC Testing** | 3w | 2015-08-24 08:00 | 2015-09-11 17:00 |  | 0d |  |  |  | 120h |
| 155 | 2.1.3.1 | Integrated Testing | 3w | 2015-08-24 08:00 | 2015-09-11 17:00 | 153 | 0d |  |  |  | 120h |
| 156 | 3 | **Cycle 3** | 2mo | 2015-07-08 08:00 | 2015-09-01 17:00 |  | 8d |  |  |  | 320h |
| 157 | 3.1 | Set up MPLS | 40d | 2015-07-08 08:00 | 2015-09-01 17:00 |  | 8d |  | start no earlier than 2015-07-08 00:00 |  | 320h |
